# Proy. Corqueamaya 2000-2003

Schedule from MS Project, 2013-04-01 to 2013-07-23.
Hewlett-Packard Company

## Calendars

- Estándar: Mon-Fri 09:00-13:00, 15:00-19:00; Sat-Sun off.

## Resources

| Resource |
| --- |
| TLC 1 |
| TLC 2 |
| Albañil 1 |
| Albañil 2 |
| Albañil 3 |
| Ayudante 1 |
| Ayudante 2 |
| Ayudante 3 |
| Ayudante 4 |
| Ayudante 5 |
| Ayudante 6 |
| Ayudante 7 |
| Ayudante 8 |
| Operador 1 |
| Operador 2 |
| Encofrador 1 |
| Encofrador 2 |
| Encofrador 3 |
| Armador 1 |
| Armador 2 |
| Plomero |
| Vibradora 1 |
| Compactador 1 |
| Vibradora 2 |
| Compactador 2 |
| Topografo 1 |
| Alarife 1 |
| Alarife 2 |
| Topografo 2 |
| Volqueta |
| Camioneta |
| Hormigonera 1 |
| Hormigonera 2 |
| Vibradora 3 |
| Vibradora 4 |
| Compactador 3 |
| Compactador 4 |
| Nivel 1 |
| Nivel 2 |
| Operador 3 |
| Chofer |
| Ayudante 9 |
| Ayudante 10 |
| Ayudante 11 |
| Ayudante 12 |
| Encofrador 4 |
| Encofrador 5 |
| Encofrador 6 |
| Albañil 4 |
| Albañil 5 |
| Albañil 6 |
| Albañil 7 |
| Ayudante 13 |
| Ayudante 14 |
| Ayudante 15 |
| Ayudante 21 |
| Ayudante 16 |
| Ayudante 17 |
| Ayudante 18 |
| Ayudante 19 |
| Ayudante 20 |
| Ayudante 22 |
| Ayudante 23 |
| Ayudante 24 |
| Ayudante 25 |
| Ayudante 26 |
| Ayudante 27 |
| Ayudante 28 |
| Ayudante 29 |
| Ayudante 30 |
| Ayudante 31 |
| Ayudante 32 |
| Ayudante 33 |
| Ayudante 34 |
| Ayudante 35 |
| Hormigonera 3 |
| Hormigonera 4 |

## Schedule

| ID | WBS | Task | Duration | Start | Finish | Predecessors | Total slack | Free slack | Constraint | Resources | Work |
| --- | --- | --- | --- | --- | --- | --- | --- | --- | --- | --- | --- |
| 1 | 1 | **PROYECTO DE RIEGO CORQUEAMAYA** | 82d | 2013-04-01 | 2013-07-23 |  | 0d |  |  |  | 15080h |
| 2 | 1.1 | **INSTALACIONES GENERALES** | 35d | 2013-04-01 | 2013-05-17 |  | 0d |  |  |  | 972h |
| 3 | 1.1.1 | Movilización de equipos | 2d | 2013-04-01 | 2013-04-02 |  | 0d |  | start no earlier than 2013-04-01 |  |  |
| 4 | 1.1.2 | Instalación de Faenas | 4d | 2013-04-02 | 2013-04-05 | 3SS+1d | 0d |  |  | Albañil 1; Ayudante 1; Ayudante 2 | 96h |
| 5 | 1.1.3 | Acopio y disposición de materiales | 30d | 2013-04-08 | 2013-05-17 | 4 | 47d |  |  | Camioneta; Operador 3; Volqueta; Chofer | 876h |
| 6 | 1.2 | **REPLANTEO Y TRAZADO** | 3d | 2013-04-08 | 2013-04-10 |  | 0d |  |  |  | 144h |
| 7 | 1.2.1 | Replanteo | 2d | 2013-04-08 | 2013-04-09 | 4 | 0d |  |  | Alarife 1; Alarife 2; Topografo 1; Topografo 2; Nivel 1; Nivel 2 | 96h |
| 8 | 1.2.2 | Trazado | 3d | 2013-04-08 | 2013-04-10 | 7SS | 0d |  |  | Ayudante 1; Ayudante 2 | 48h |
| 9 | 1.3 | **TANQUE DE ALMACENAMIENTO** | 69d | 2013-04-11 | 2013-07-16 |  | 0d |  |  |  | 4024h |
| 10 | 1.3.1 | Excavación (0-2 m) suelo semiduro | 10d | 2013-04-11 | 2013-04-24 | 8 | 0d |  |  | TLC 2; Ayudante 2; Operador 2 | 240h |
| 11 | 1.3.2 | H°C° Fundaciones (1:2:4) 50% Piedra Desplazadora | 10d | 2013-04-25 | 2013-05-08 | 10 | 0d |  |  | Ayudante 3; Ayudante 4; Ayudante 5; Ayudante 6; Ayudante 7; Ayudante 8; Encofrador 1; Vibradora 1; Vibradora 2; Hormigonera 1 | 760h |
| 12 | 1.3.3 | Hormigón armado - fundación | 10d | 2013-05-10 | 2013-05-23 | 11SS+11d | 0d |  |  | Albañil 4; Albañil 5; Armador 1; Armador 2; Ayudante 24; Ayudante 32; Ayudante 20; Ayudante 8; Vibradora 3; Encofrador 1; Hormigonera 1 | 856h |
| 13 | 1.3.4 | H°C° Elevaciones (1:2:4) 50% Piedra Desplazadora | 20d | 2013-05-29 | 2013-06-25 | 12SS+13d | 0d |  |  | Albañil 4; Albañil 1; Ayudante 10; Ayudante 17; Ayudante 6; Ayudante 7; Ayudante 8; Encofrador 1; Encofrador 2; Hormigonera 1 | 1600h |
| 14 | 1.3.5 | Provisión e instalación de accesorios de Tanque | 3d | 2013-06-10 | 2013-06-12 | 13SS+8d | 24d |  |  | Albañil 3; Ayudante 1; Ayudante 2; Plomero | 88h |
| 15 | 1.3.6 | Revoque de mortero con aditivo impermeabilizante 1:3 E=2 cm | 10d | 2013-06-26 | 2013-07-09 | 13 | 0d |  |  | Albañil 1; Ayudante 1; Albañil 2; Ayudante 2 | 320h |
| 16 | 1.3.7 | Revoque exterior con cemento | 5d | 2013-07-10 | 2013-07-16 | 15 | 0d |  |  | Albañil 1; Ayudante 1; Albañil 2; Ayudante 2 | 160h |
| 17 | 1.4 | **OBRA DE TOMA** | 31d | 2013-04-11 | 2013-05-23 |  | 29d |  |  |  | 2860h |
| 18 | 1.4.1 | Excavación (0-2 m) con bomba de agua | 10d | 2013-04-11 | 2013-04-24 | 7SS+3d | 29d | 0d |  | TLC 1; Operador 1; Ayudante 1 | 240h |
| 19 | 1.4.2 | H°C° Fundaciones (1:2:4) 50% Piedra Desplazadora | 16d | 2013-04-25 | 2013-05-16 | 18 | 43d | 0d |  | Ayudante 11; Ayudante 12; Ayudante 13; Ayudante 14; Ayudante 9; Ayudante 10; Encofrador 4; Vibradora 3; Vibradora 4; Hormigonera 2 | 1256h |
| 20 | 1.4.3 | H°C° Elevaciones (1:2:4) 50% Piedra Desplazadora | 16d | 2013-04-29 | 2013-05-20 | 19SS+2d | 43d | 0d |  | Albañil 1; Albañil 2; Ayudante 22; Ayudante 25; Ayudante 19; Ayudante 18; Ayudante 17; Encofrador 3; Encofrador 2; Hormigonera 4 | 1280h |
| 21 | 1.4.4 | Provisión y colocación de Accesorios de obra de toma | 2d | 2013-05-21 | 2013-05-22 | 20 | 43d | 0d |  | Albañil 2; Ayudante 3; Ayudante 12; Plomero | 56h |
| 22 | 1.4.5 | Filtro con material drenante | 1d | 2013-05-23 | 2013-05-23 | 21 | 43d |  |  | Albañil 2; Ayudante 3; Ayudante 2; Plomero | 28h |
| 23 | 1.5 | **DESARENADOR** | 14d | 2013-04-25 | 2013-05-14 |  | 29d |  |  |  | 822h |
| 24 | 1.5.1 | Excavación (0-2 m) suelo semiduro | 2d | 2013-04-25 | 2013-04-26 | 18 | 29d | 0d |  | TLC 1; Operador 1; Ayudante 1 | 48h |
| 25 | 1.5.2 | H°C° Fundaciones (1:2:4) 50% Piedra Desplazadora | 5d | 2013-04-29 | 2013-05-03 | 24 | 50d | 0d |  | Ayudante 21; Ayudante 15; Ayudante 27; Ayudante 24; Ayudante 20; Ayudante 30; Encofrador 5; Vibradora 1; Vibradora 2; Hormigonera 3 | 360h |
| 26 | 1.5.3 | H°C° Elevaciones (1:2:4) 50% Piedra Desplazadora | 4d | 2013-05-06 | 2013-05-09 | 25 | 50d | 0d |  | Albañil 7; Albañil 6; Ayudante 23; Ayudante 32; Ayudante 35; Ayudante 27; Ayudante 24; Encofrador 6; Encofrador 5; Hormigonera 3 | 312h |
| 27 | 1.5.4 | Provisión e instalación de accesorios de Desarenador | 1d | 2013-05-09 | 2013-05-09 | 26SS+3d | 53d |  |  | Albañil 3; Ayudante 20; Ayudante 8; Plomero | 24h |
| 28 | 1.5.5 | Revoque interior con cemento | 3d | 2013-05-10 | 2013-05-14 | 26 | 50d |  |  | Albañil 3; Ayudante 23; Ayudante 27; Plomero | 78h |

| ID | WBS | Task | Duration | Start | Finish | Predecessors | Total slack | Free slack | Resources | Work |
| --- | --- | --- | --- | --- | --- | --- | --- | --- | --- | --- |
| 29 | 1.6 | **TENDIDO DE TUBERÍA DE ADUCCIÓN** | 35d | 2013-04-25 | 2013-06-12 |  | 29d |  |  | 2592h |
| 30 | 1.6.1 | Excavación (0-2 m) suelo semiduro | 20d | 2013-04-25 | 2013-05-22 | 10 | 29d | 0d | TLC 2; Ayudante 2; Operador 2 | 480h |
| 31 | 1.6.2 | Relleno y compactado manual con tierra cernida | 30d | 2013-05-02 | 2013-06-12 | 30SS+5d | 29d | 0d | Ayudante 16; Ayudante 29; Ayudante 28; Ayudante 26; Compactador 1; Compactador 3 | 1440h |
| 32 | 1.6.3 | Provisión y colocación de Tubería PVC Clase 9 | 20d | 2013-05-06 | 2013-05-31 | 31SS+2d | 35d | 0d | Albañil 6; Ayudante 15; Ayudante 31; Camioneta; Chofer; Plomero | 664h |
| 33 | 1.6.4 | Prueba hidráulica | 2d | 2013-06-03 | 2013-06-04 | 32 | 35d |  | Plomero | 8h |
| 34 | 1.7 | **TENDIDO DE TUBERÍA DE DISTRIBUCIÓN** | 30d | 2013-04-29 | 2013-06-07 |  | 29d |  |  | 2050h |
| 35 | 1.7.1 | Excavación (0-2 m) suelo semiduro | 15d | 2013-04-29 | 2013-05-17 | 24 | 29d | 0d | TLC 1; Operador 1; Ayudante 1 | 360h |
| 36 | 1.7.2 | Relleno y compactado manual con tierra cernida | 25d | 2013-05-06 | 2013-06-07 | 35SS+5d | 32d | 0d | Ayudante 21; Ayudante 33; Ayudante 30; Ayudante 34; Compactador 2; Compactador 4 | 1200h |
| 37 | 1.7.3 | Provisión y colocación de Tubería PVC Clase 9 | 15d | 2013-05-09 | 2013-05-29 | 36SS+3d | 35d | 0d | Albañil 3; Ayudante 4; Ayudante 5; Camioneta; Chofer; Plomero | 474h |
| 38 | 1.7.4 | Prueba hidráulica | 4d | 2013-05-30 | 2013-06-04 | 37 | 35d |  | Plomero | 16h |
| 39 | 1.8 | **CAJAS DE DISTRIBUCIÓN DE RIEGO** | 18d | 2013-05-20 | 2013-06-12 |  | 29d |  |  | 976h |
| 40 | 1.8.1 | Excavación (0-2 m) suelo semiduro | 5d | 2013-05-20 | 2013-05-24 | 35 | 29d | 0d | TLC 1; Operador 1; Ayudante 1 | 120h |
| 41 | 1.8.2 | H°C° Elevaciones (1:2:4) 50% Piedra Desplazadora | 10d | 2013-05-30 | 2013-06-12 | 40FS+3d | 29d | 0d | Albañil 2; Albañil 5; Ayudante 4; Ayudante 5; Ayudante 19; Ayudante 12; Ayudante 22; Encofrador 4; Encofrador 3; Hormigonera 2 | 800h |
| 42 | 1.8.3 | Provisión e instalación de accesorios de Cajas de Distribución | 2d | 2013-06-07 | 2013-06-10 | 41SS+6d | 31d |  | Albañil 6; Ayudante 24; Ayudante 23; Plomero | 56h |
| 43 | 1.9 | LIMPIEZA GENERAL | 5d | 2013-07-17 | 2013-07-23 | 9 | 0d |  | Ayudante 1; Ayudante 2; Ayudante 3; Ayudante 4; Ayudante 5; Ayudante 6; Ayudante 7; Ayudante 8; Camioneta; Chofer; Operador 1; Operador 2; Operador 3; TLC 1; TLC 2; Volqueta | 640h |
